# E-FIT.PM.Sample Project

Schedule from MS Project, 2019-02-01 to 2019-12-16, costs in р., A marks actual dates.
Intelli

## Calendars

- Standard: Mon-Fri 08:00-12:00, 13:00-17:00; Sat-Sun off.

## Resources

| Resource | Rate |
| --- | --- |
| System Architect | 1000 |
| Java developer 2 | 1000 |
| Java developer 3 | 1000 |
| Java developer 4 | 1000 |
| Project Manager | 1000 |
| Database Architect | 1000 |
| Test Designer | 1000 |
| Tester | 1000 |
| Java developer | 1000 |
| Analyst |  |

## Schedule

| ID | WBS | Task | Type | Duration | Start | Finish | Predecessors | Complete | Remaining | Baseline start | Baseline finish | Baseline duration | Total slack | Free slack | Constraint | Resources | Work | Actual work | Cost | Baseline cost | Actual cost |
| --- | --- | --- | --- | --- | --- | --- | --- | --- | --- | --- | --- | --- | --- | --- | --- | --- | --- | --- | --- | --- | --- |
| 1 | 1 | **Название проекта** |  | 227d | 2019-02-01 A | 2019-12-16 |  | 46% | 123.69d | 2005-03-01 | 2005-04-01 | 24d | 0d |  |  |  | 378h | 106h | 345,000 | 10,000 | 85,000 |
| 2 | 1.1 | **Техническое задание (2 семестр)** |  | 72d | 2019-02-01 A | 2019-05-13 A |  | 100% |  | 2005-03-01 | 2005-03-01 | 1d |  |  |  |  | 106h | 106h | 85,000 | 400 | 85,000 |
| 3 | 1.1.1 | Формирование команды |  | 10d | 2019-02-01 A | 2019-02-14 A |  | 100% |  |  |  |  |  |  |  | Project Manager [10%] | 8h | 8h | 8,000 |  | 8,000 |
| 4 | 1.1.2 | Управление проектом |  | 70d | 2019-02-01 A | 2019-05-09 A |  | 100% |  |  |  |  |  |  |  | Project Manager [50%] | 10h | 10h | 10,000 |  | 10,000 |
| 5 | 1.1.3 | Анализ требований |  | 30d | 2019-02-01 A | 2019-03-14 A |  | 100% |  | 2005-03-01 | 2005-03-01 | 1d |  |  |  | Analyst | 16h | 16h |  | 400 |  |
| 6 | 1.1.4 | Архитектура |  | 10d | 2019-03-01 A | 2019-03-14 A | 5FF | 100% |  |  |  |  |  |  |  | System Architect | 16h | 16h | 16,000 |  | 16,000 |
| 7 | 1.1.5 | Анализ рисков |  | 20.08d | 2019-03-15 A | 2019-04-12 A | 6 | 100% |  |  |  |  |  |  |  | Project Manager; System Architect; Analyst | 16h | 16h | 11,000 |  | 11,000 |
| 8 | 1.1.6 | Разработка плана проекта |  | 20d | 2019-03-15 A | 2019-04-11 A | 5 | 100% |  |  |  |  |  |  |  | Project Manager | 16h | 16h | 16,000 |  | 16,000 |
| 9 | 1.1.7 | Формирование штатного расписания |  | 2d | 2019-04-12 A | 2019-04-15 A | 8 | 100% |  |  |  |  |  |  |  | Project Manager | 16h | 16h | 16,000 |  | 16,000 |
| 10 | 1.1.8 | Подготовка документа ТЗ |  | 20d | 2019-04-16 A | 2019-05-13 A | 7, 9 | 100% |  |  |  |  |  |  |  | Project Manager | 8h | 8h | 8,000 |  | 8,000 |
| 11 | 1.1.9 | Этап ТЗ завершен | milestone | 0d | 2019-05-13 A | 2019-05-13 A | 10 | 100% |  |  |  |  |  |  |  |  |  |  |  |  |  |
| 12 | 1.2 | **Реализация (3 семестр)** |  | 76d | 2019-09-02 | 2019-12-16 | 2 |  |  |  |  |  | 0d |  | start no earlier than 2019-09-01 |  | 272h |  | 260,000 |  |  |
| 13 | 1.2.1 | Формирование команды |  | 5d | 2019-09-02 | 2019-09-06 |  |  |  |  |  |  | 0d |  |  | Project Manager [10%]; Analyst [10%] | 8h |  | 4,000 |  |  |
| 14 | 1.2.2 | Управление проектом |  | 70d | 2019-09-09 | 2019-12-13 | 13 |  |  |  |  |  | 1d |  |  | Project Manager [7.1%] | 40h |  | 40,000 |  |  |
| 15 | 1.2.3 | **Уточнение** |  | 20d | 2019-09-09 | 2019-10-04 | 13 |  |  | 2005-03-02 | 2005-03-09 | 5.5d | 0d |  |  |  | 56h |  | 48,000 | 2,200 |  |
| 16 | 1.2.3.1 | Функциональный прототип |  | 10d | 2019-09-09 | 2019-09-20 |  |  |  | 2005-03-02 | 2005-03-03 | 2d | 0d |  |  | Java developer | 20h |  | 20,000 | 800 |  |
| 17 | 1.2.3.2 | Обсуждение прототипа |  | 10d | 2019-09-23 | 2019-10-04 | 16 |  |  | 2005-03-04 | 2005-03-09 | 3.5d | 0d |  |  | Analyst | 8h |  |  | 1,400 |  |
| 18 | 1.2.3.3 | Архитектурный прототип |  | 10d | 2019-09-09 | 2019-09-20 |  |  |  |  |  |  | 5d | 0d |  | Java developer | 20h |  | 20,000 |  |  |
| 19 | 1.2.3.4 | Стресс-тестирование |  | 5d | 2019-09-23 | 2019-09-27 | 18 |  |  |  |  |  | 5d |  |  | Java developer | 8h |  | 8,000 |  |  |
| 20 | 1.2.3.5 | Уточнение завершено | milestone | 0d | 2019-10-04 | 2019-10-04 | 19, 17 |  |  |  |  |  | 0d |  |  |  |  |  |  |  |  |
| 21 | 1.2.4 | **Разработка** |  | 38d | 2019-10-07 | 2019-11-27 | 15 |  |  | 2005-03-09 | 2005-03-24 | 11.5d | 0d |  |  |  | 128h |  | 128,000 | 5,400 |  |
| 22 | 1.2.4.1 | Контроль за соблюдением архитектуры и контроль кода |  | 33d | 2019-10-07 | 2019-11-20 |  |  |  | 2005-03-09 | 2005-03-14 | 3d | 0d |  |  | System Architect | 24h |  | 24,000 | 1,200 |  |
| 23 | 1.2.4.2 | Схема БД |  | 5d | 2019-10-08 | 2019-10-14 | 22SS+1d |  |  | 2005-03-10 | 2005-03-11 | 1d | 0d |  |  | Database Architect | 8h |  | 8,000 | 400 |  |
| 24 | 1.2.4.3 | Бизнес-логика |  | 20d | 2019-10-15 | 2019-11-11 | 22SS, 23 |  |  | 2005-03-14 | 2005-03-16 | 2.5d | 0d |  | start no earlier than 2004-04-02 | Java developer | 32h |  | 32,000 | 1,000 |  |
| 25 | 1.2.4.4 | Пользовательский интерфейс |  | 20d | 2019-10-17 | 2019-11-13 | 24SS+2d |  |  | 2005-03-17 | 2005-03-23 | 5d | 0d |  | start no earlier than 2004-03-31 | Java developer | 40h |  | 40,000 | 2,000 |  |
| 26 | 1.2.4.5 | Инсталляционный пакет |  | 5d | 2019-11-14 | 2019-11-20 | 25, 24 |  |  | 2005-03-24 | 2005-03-24 | 1d | 5d |  |  | Java developer | 8h |  | 8,000 | 400 |  |
| 27 | 1.2.4.6 | План тестирования |  | 10d | 2019-11-14 | 2019-11-27 | 24, 25 |  |  | 2005-03-14 | 2005-03-15 | 1d | 0d |  | start no earlier than 2004-04-02 | Test Designer | 16h |  | 16,000 | 400 |  |

| ID | WBS | Task | Type | Duration | Start | Finish | Predecessors | Baseline start | Baseline finish | Baseline duration | Total slack | Deadline | Resources | Work | Cost | Baseline cost |
| --- | --- | --- | --- | --- | --- | --- | --- | --- | --- | --- | --- | --- | --- | --- | --- | --- |
| 28 | 1.2.5 | **Приемка/передача** |  | 11d | 2019-12-02 | 2019-12-16 | 21FS+2d | 2005-03-29 | 2005-04-01 | 4d | 0d |  |  | 40h | 40,000 | 2,000 |
| 29 | 1.2.5.1 | Тестирование |  | 5d | 2019-12-02 | 2019-12-06 |  | 2005-03-29 | 2005-03-30 | 2d | 0d |  | Tester | 16h | 16,000 | 800 |
| 30 | 1.2.5.2 | Исправление ошибок |  | 5d | 2019-12-03 | 2019-12-09 | 29SS+1d | 2005-03-30 | 2005-03-31 | 2d | 0d |  | Java developer | 16h | 16,000 | 800 |
| 31 | 1.2.5.3 | Установка на полигон |  | 5d | 2019-12-10 | 2019-12-16 | 30, 29 | 2005-04-01 | 2005-04-01 | 1d | 0d |  | Java developer | 8h | 8,000 | 400 |
| 32 | 1.3 | Проект завершен | milestone | 0d | 2019-12-16 | 2019-12-16 | 28 | 2005-04-01 | 2005-04-01 | 0d | 0d | 2019-12-31 |  |  |  |  |
