# E-FIT.PM.Sample Project

Schedule from MS Project, 2025-02-03 to 2025-12-19, costs in р., A marks actual dates.
Intelli

## Calendars

- Standard: Mon-Fri 08:00-12:00, 13:00-17:00; Sat-Sun off.

## Resources

| Resource | Rate |
| --- | --- |
| System Architect | 1000 |
| Java developer 2 | 1000 |
| Java developer 3 | 1000 |
| Java developer 4 | 1000 |
| Project Manager | 1000 |
| Database Architect | 1000 |
| Test Designer | 1000 |
| Tester | 1000 |
| Java developer | 1000 |
| Analyst |  |
| UI developer |  |

## Schedule

| ID | WBS | Task | Type | Duration | Start | Finish | Predecessors | Complete | Remaining | Baseline start | Baseline finish | Baseline duration | Total slack | Free slack | Constraint | Resources | Work | Actual work | Cost | Baseline cost | Actual cost |
| --- | --- | --- | --- | --- | --- | --- | --- | --- | --- | --- | --- | --- | --- | --- | --- | --- | --- | --- | --- | --- | --- |
| 1 | 1 | **Название проекта** |  | 230d | 2025-02-03 A | 2025-12-19 |  | 34% | 151.32d | 2022-02-01 | 2022-12-15 | 228d | 0d |  |  |  | 498h | 106h | 345,000 | 345,000 | 85,000 |
| 2 | 1.1 | **Техническое задание (2 семестр)** |  | 72d | 2025-02-03 A | 2025-05-13 A |  | 100% |  | 2022-02-01 | 2022-05-11 | 72d |  |  |  |  | 106h | 106h | 85,000 | 85,000 | 85,000 |
| 3 | 1.1.1 | Формирование команды |  | 10d | 2025-02-03 A | 2025-02-14 A |  | 100% |  | 2022-02-01 | 2022-02-14 | 10d |  |  |  | Project Manager [10%] | 8h | 8h | 8,000 | 8,000 | 8,000 |
| 4 | 1.1.2 | Управление проектом |  | 70d | 2025-02-03 A | 2025-05-09 A |  | 100% |  | 2022-02-01 | 2022-05-09 | 70d |  |  |  | Project Manager [50%] | 10h | 10h | 10,000 | 10,000 | 10,000 |
| 5 | 1.1.3 | Анализ требований |  | 30d | 2025-02-03 A | 2025-03-14 A |  | 100% |  | 2022-02-01 | 2022-03-14 | 30d |  |  |  | Analyst | 16h | 16h |  |  |  |
| 6 | 1.1.4 | Архитектура |  | 10d | 2025-03-03 A | 2025-03-14 A | 5FF | 100% |  | 2022-03-01 | 2022-03-14 | 10d |  |  |  | System Architect | 16h | 16h | 16,000 | 16,000 | 16,000 |
| 7 | 1.1.5 | Анализ рисков |  | 20d | 2025-03-17 A | 2025-04-11 A | 6 | 100% |  | 2022-03-15 | 2022-04-11 | 20d |  |  |  | Project Manager; System Architect; Analyst | 16h | 16h | 11,000 | 11,000 | 11,000 |
| 8 | 1.1.6 | Разработка плана проекта |  | 20d | 2025-03-17 A | 2025-04-11 A | 5 | 100% |  | 2022-03-15 | 2022-04-11 | 20d |  |  |  | Project Manager | 16h | 16h | 16,000 | 16,000 | 16,000 |
| 9 | 1.1.7 | Формирование штатного расписания |  | 2d | 2025-04-14 A | 2025-04-15 A | 8 | 100% |  | 2022-04-12 | 2022-04-13 | 2d |  |  |  | Project Manager | 16h | 16h | 16,000 | 16,000 | 16,000 |
| 10 | 1.1.8 | Подготовка документа ТЗ |  | 20d | 2025-04-16 A | 2025-05-13 A | 7, 9 | 100% |  | 2022-04-14 | 2022-05-11 | 20d |  |  |  | Project Manager | 8h | 8h | 8,000 | 8,000 | 8,000 |
| 11 | 1.1.9 | Этап ТЗ завершен | milestone | 0d | 2025-05-13 A | 2025-05-13 A | 10 | 100% |  | 2022-05-11 | 2022-05-11 | 0d |  |  |  |  |  |  |  |  |  |
| 12 | 1.2 | **Реализация (3 семестр)** |  | 80d | 2025-09-01 | 2025-12-19 | 2 |  |  | 2022-09-01 | 2022-12-15 | 76d | 0d |  | start no earlier than 2025-09-01 |  | 392h |  | 260,000 | 260,000 |  |
| 13 | 1.2.1 | Формирование команды |  | 5d | 2025-09-01 | 2025-09-05 |  |  |  | 2022-09-01 | 2022-09-07 | 5d | 0d |  |  | Project Manager [10%]; Analyst [10%] | 8h |  | 4,000 | 4,000 |  |
| 14 | 1.2.2 | Управление проектом |  | 70d | 2025-09-08 | 2025-12-12 | 13 |  |  | 2022-09-08 | 2022-12-14 | 70d | 5d |  |  | Project Manager [7.1%] | 40h |  | 40,000 | 40,000 |  |
| 15 | 1.2.3 | Управление изменениями требований |  | 70d | 2025-09-08 | 2025-12-12 | 13 |  |  |  |  |  | 5d |  |  | Analyst | 40h |  |  |  |  |
| 16 | 1.2.4 | Контроль за соблюдением архитектуры и контроль кода |  | 70d | 2025-09-08 | 2025-12-12 | 13 |  |  | 2022-10-06 | 2022-11-21 | 33d | 5d |  |  | System Architect | 40h |  | 40,000 | 24,000 |  |
| 17 | 1.2.5 | **Спринт 1 - Уточнение** |  | 20d | 2025-09-08 | 2025-10-03 | 13 |  |  | 2022-09-08 | 2022-10-05 | 20d | 0d |  |  |  | 72h |  | 64,000 | 48,000 |  |
| 18 | 1.2.5.1 | Функциональный прототип |  | 10d | 2025-09-08 | 2025-09-19 |  |  |  | 2022-09-08 | 2022-09-21 | 10d | 0d |  |  | Java developer | 20h |  | 20,000 | 20,000 |  |
| 19 | 1.2.5.2 | Обсуждение прототипа |  | 10d | 2025-09-22 | 2025-10-03 | 18 |  |  | 2022-09-22 | 2022-10-05 | 10d | 0d |  |  | Analyst | 8h |  |  |  |  |
| 20 | 1.2.5.3 | Архитектурный прототип |  | 10d | 2025-09-08 | 2025-09-19 |  |  |  | 2022-09-08 | 2022-09-21 | 10d | 5d | 0d |  | Java developer | 20h |  | 20,000 | 20,000 |  |
| 21 | 1.2.5.4 | Стресс-тестирование |  | 5d | 2025-09-22 | 2025-09-26 | 20 |  |  | 2022-09-22 | 2022-09-28 | 5d | 5d |  |  | Java developer | 8h |  | 8,000 | 8,000 |  |
| 22 | 1.2.5.5 | Уточнение завершено | milestone | 0d | 2025-10-03 | 2025-10-03 | 21, 19 |  |  | 2022-10-05 | 2022-10-05 | 0d | 0d |  |  |  |  |  |  |  |  |
| 23 | 1.2.5.6 | План тестирования |  | 10d | 2025-09-08 | 2025-09-19 |  |  |  | 2022-11-15 | 2022-11-28 | 10d | 10d |  |  | Test Designer | 16h |  | 16,000 | 16,000 |  |
| 24 | 1.2.6 | **Спринт 2 - Фича 1** |  | 22d | 2025-10-06 | 2025-11-04 | 17 |  |  | 2022-10-06 | 2022-11-28 | 38d | 0d |  |  |  | 80h |  | 40,000 | 128,000 |  |
| 25 | 1.2.6.1 | Схема БД |  | 5d | 2025-10-06 | 2025-10-10 |  |  |  | 2022-10-07 | 2022-10-13 | 5d | 0d |  |  | Database Architect | 8h |  | 8,000 | 8,000 |  |
| 26 | 1.2.6.2 | фича 1 - бекенд |  | 15d | 2025-10-13 | 2025-10-31 | 25 |  |  | 2022-10-14 | 2022-11-10 | 20d | 0d |  |  | Java developer | 32h |  | 32,000 | 32,000 |  |
| 27 | 1.2.6.3 | фича 1 - фронтенд |  | 15d | 2025-10-15 | 2025-11-04 | 26SS+2d |  |  | 2022-10-18 | 2022-11-14 | 20d | 0d |  |  | UI developer | 40h |  |  | 40,000 |  |

| ID | WBS | Task | Type | Duration | Start | Finish | Predecessors | Baseline start | Baseline finish | Baseline duration | Total slack | Deadline | Resources | Work | Cost | Baseline cost |
| --- | --- | --- | --- | --- | --- | --- | --- | --- | --- | --- | --- | --- | --- | --- | --- | --- |
| 28 | 1.2.7 | **Спринт 3 - Фича 2** |  | 20d | 2025-11-05 | 2025-12-02 | 24 |  |  |  | 0d |  |  | 72h | 32,000 |  |
| 29 | 1.2.7.1 | фича 2 - бекенд |  | 20d | 2025-11-05 | 2025-12-02 |  |  |  |  | 0d |  | Java developer | 32h | 32,000 |  |
| 30 | 1.2.7.2 | фича 2 - фронтенд |  | 20d | 2025-11-05 | 2025-12-02 |  |  |  |  | 0d |  | UI developer | 40h |  |  |
| 31 | 1.2.8 | **Спринт 4 - Приемка/передача** |  | 11d | 2025-12-05 | 2025-12-19 | 28FS+2d | 2022-12-01 | 2022-12-15 | 11d | 0d |  |  | 40h | 40,000 | 40,000 |
| 32 | 1.2.8.1 | Финальное тестирование |  | 5d | 2025-12-05 | 2025-12-11 |  | 2022-12-01 | 2022-12-07 | 5d | 0d |  | Tester | 16h | 16,000 | 16,000 |
| 33 | 1.2.8.2 | Исправление ошибок |  | 5d | 2025-12-08 | 2025-12-12 | 32SS+1d | 2022-12-02 | 2022-12-08 | 5d | 0d |  | Java developer | 16h | 16,000 | 16,000 |
| 34 | 1.2.8.3 | Установка на полигон |  | 5d | 2025-12-15 | 2025-12-19 | 33, 32 | 2022-12-09 | 2022-12-15 | 5d | 0d |  | Java developer | 8h | 8,000 | 8,000 |
| 35 | 1.3 | Проект завершен | milestone | 0d | 2025-12-19 | 2025-12-19 | 31 | 2022-12-15 | 2022-12-15 | 0d | 0d | 2025-12-25 |  |  |  |  |
